# PROYECTO 02 RÍO HUARMEY SECTOR 2 PARTE BAJA

Schedule from Primavera P6, 2023-04-24 to 2024-06-24, data date 2023-04-24.

## Calendars

- 2T - 6x1 - 8 hr - Ríos: Mon-Sat 02:00-06:00, 08:00-12:00, 14:00-18:00, 20:00-00:00; Sun off. Exceptions (off unless hours are given): 2023-05-01, 2023-06-29, 2023-07-28 to 2023-07-29, 2023-08-30, 2023-11-01, 2023-12-08, 2023-12-16, 2023-12-18 to 2023-12-23, 2023-12-25 to 2023-12-30, 2024-01-01 to 2024-01-06, 2024-01-08 to 2024-01-13, 2024-01-15 to 2024-01-20, 2024-01-22 to 2024-01-27, 2024-01-29 to 2024-02-03, 2024-02-05 to 2024-02-10, 2024-02-12 to 2024-02-17, 2024-02-19 to 2024-02-24, 2024-02-26 to 2024-03-02, 2024-03-04 to 2024-03-09, 2024-03-11 to 2024-03-15, 2024-05-01.
- 2T - 6x1 - 8 hr: Mon-Sat 02:00-06:00, 08:00-12:00, 14:00-18:00, 20:00-00:00; Sun off. Exceptions (off unless hours are given): 2023-05-01, 2023-06-29, 2023-07-28 to 2023-07-29, 2023-08-30, 2023-11-01, 2023-12-08, 2023-12-25, 2024-01-01, 2024-03-28 to 2024-03-29, 2024-05-01.

## Schedule

| ID | WBS | Activity | Type | Duration | Start | Finish | Predecessors | Total float | Free float | Calendar |
| --- | --- | --- | --- | --- | --- | --- | --- | --- | --- | --- |
|  | 0 | **HITOS** |  |  | 2023-04-24 | 2024-06-20 |  |  |  |  |
| A1000 |  | ADJUDICACIÓN | milestone | 0d | 2023-04-24 | 2023-04-24 |  | 0d |  | 2T - 6x1 - 8 hr |
| A1010 |  | INICIO DE PROYECTO | milestone | 0d | 2023-05-09 | 2023-05-09 | A1000 FS+12d | 0d |  | 2T - 6x1 - 8 hr |
| A1020 |  | FIN DE PROYECTO | milestone | 0d | 2024-06-20 | 2024-06-20 | A1070, A1100, A1120, A1240, A1270, A1280, A1290, A1300, A1310, A1320, A1440, A1620, A1710, A1900, A1910, A1970, A1030 | 0d |  | 2T - 6x1 - 8 hr |
|  | 1 | **CONSTRUCCIÓN DE DEFENSAS RIBEREÑAS** |  |  | 2023-05-09 | 2024-06-24 |  |  |  |  |
|  | 1 | **OBRAS PROVISIONALES** |  |  | 2023-05-24 | 2023-06-23 |  |  |  |  |
| A1030 |  | CARTEL DE IDENTIFICACION DE LA OBRA DE 3.60M X 2.40M. |  | 2d | 2023-05-24 | 2023-05-26 | A1040 SS | 324d |  | 2T - 6x1 - 8 hr |
| A1040 |  | INSTALACIÓN DE FACILIDADES Y CAMPAMENTOS |  | 26d | 2023-05-24 | 2023-06-23 | A1080 SS+6d | 0d |  | 2T - 6x1 - 8 hr |
|  | 2 | **OBRAS PRELIMINARES** |  |  | 2023-05-09 | 2024-06-24 |  |  |  |  |
| A1050 |  | MOVILIZACIÓN DE EQUIPOS Y/O MAQUINARIA |  | 52d | 2023-05-09 | 2023-07-09 | A1010 | 0d |  | 2T - 6x1 - 8 hr |
| A1060 |  | TRAZO, NIVELACION Y REPLANTEO PRELIMINAR |  | 58d | 2023-05-12 | 2023-07-20 | A1050 SS+3.75d | 0d |  | 2T - 6x1 - 8 hr |
| A1080 |  | HABILITACIÓN DE ACCESOS |  | 63d | 2023-05-17 | 2023-08-02 | A1060 SS+3.75d | 0d |  | 2T - 6x1 - 8 hr |
| A1090 |  | DESVÍO Y MANEJO DE AGUAS SUPERFICIALES |  | 17d | 2023-05-26 | 2023-06-15 | A1080 SS+7.5d | 21.5d | 0d | 2T - 6x1 - 8 hr |
| A1100 |  | MANTENIMIENTO DE TRÁNSITO Y SEGURIDAD VIAL EN ACCESOS A LA OBRA Y ÁREAS |  | 320d | 2023-05-26 | 2024-06-15 | A1080 SS+7.5d | 4.5d |  | 2T - 6x1 - 8 hr |
| A1070 |  | CONTROL TOPOGRAFICO DURANTE LA EJECUCIÓN |  | 315d | 2023-06-01 | 2024-06-15 | A1060 SS+17d | 3.75d |  | 2T - 6x1 - 8 hr |
| A1980 |  | DESMOVILIZACIÓN DE EQUIPOS Y/O MAQUINARIA |  | 26d | 2024-05-24 | 2024-06-24 | A1020 FF+3d | 0d |  | 2T - 6x1 - 8 hr |
|  | 3 | **OPERACIÓN Y EXPLOTACION DE MATERIAL** |  |  | 2023-05-31 | 2024-02-21 |  |  |  |  |
| A1110 |  | EXPLOTACION Y PREPARACION DE MATERIAL PARA CONFORMACION DE DIQUE |  | 220d | 2023-05-31 | 2024-02-21 | A1130 SS | 7d |  | 2T - 6x1 - 8 hr |
| A1120 |  | EXPLOTACION Y PREPARACION DE MATERIAL PARA AFIRMADO |  | 220d | 2023-05-31 | 2024-02-21 | A1130 SS | 100d |  | 2T - 6x1 - 8 hr |
| A1130 |  | PREPARACIÓN DE MATERIAL PROPIO |  | 220d | 2023-05-31 | 2024-02-21 | A1040 SS+6d | 7d | 0d | 2T - 6x1 - 8 hr |
|  | 4 | **MOVIMIENTO DE TIERRAS** |  |  | 2023-05-24 | 2024-06-20 |  |  |  |  |
|  | 1 | **CONSTRUCCIÓN DE DIQUE NUEVO** |  |  | 2023-06-15 | 2024-06-20 |  |  |  |  |
| A1220 |  | DESCOLMATACIÓN DEL CAUCE |  | 131d | 2023-06-15 | 2023-11-21 | A1090 | 21.5d | 0d |  |
| A1270 |  | CONFORMACIÓN DE DME/DMO |  | 212d | 2023-06-15 | 2024-05-26 | A1220 SS | 21.5d |  |  |
| A1140 |  | DESBROCE Y LIMPIEZA |  | 167d | 2023-06-24 | 2024-04-12 | A1350 | 0d |  |  |
| A1150 |  | EXCAVACIÓN MASIVA EN MATERIAL SUELTO, CON EQUIPO |  | 167d | 2023-06-24 | 2024-04-12 | A1140 SS | 0d |  |  |
| A1160 |  | EXCAVACIÓN EN ROCA SUELTA CON EQUIPO |  | 167d | 2023-06-24 | 2024-04-12 | A1350, A1150 SS | 0d |  |  |
| A1170 |  | EXCAVACIÓN DE ROCA FIJA CON MARTILLO HIDRÁULICO |  | 167d | 2023-06-24 | 2024-04-12 | A1160 SS | 0d |  |  |
| A1180 |  | EXCAVACION DE UÑA EN MATERIAL CON NIVEL FREATICO |  | 165d | 2023-07-03 | 2024-04-17 | A1170 SS+6d, A1360 | 0d |  |  |
| A1330 |  | CONFORMACIÓN DE SUBRASANTE |  | 150d | 2023-07-03 | 2024-03-30 | A1180 SS | 0d |  |  |
| A1190 |  | CONFORMACIÓN Y COMPACTACIÓN DE DIQUE |  | 175d | 2023-07-10 | 2024-05-07 | A1370, A1110 SS+26d, A1330 SS+6d | 0d |  |  |
| A1230 |  | REFINE Y PERFILADO DE TALUD |  | 150d | 2023-07-17 | 2024-04-13 | A1190 SS+6d | 0d |  |  |
| A1240 |  | ZANJA Y RELLENO PARA ANCLAJE DE GEOTEXTIL |  | 150d | 2023-08-02 | 2024-04-27 | A1250 SS | 45d |  |  |
| A1250 |  | GEOTEXTIL NO TEJIDO CLASE 1, INCLUYE INSTALACIÓN |  | 186d | 2023-08-02 | 2024-06-10 | A1230 SS+12d, A1400 | 0d |  |  |
| A1260 |  | GEOTEXTIL NO TEJIDO CLASE 2, INCLUYE INSTALACIÓN |  | 186d | 2023-08-02 | 2024-06-10 | A1250 SS | 0.5d | 0d |  |
| A1210 |  | ENROCADO Y ACOMODO DE ROCA EN UÑA ANTISOCAVANTE TIPO 1 |  | 144d | 2023-08-09 | 2024-04-27 | A1250 SS+6d, A1390 | 0d |  |  |
| A1200 |  | ENROCADO Y ACOMODO DE ROCA PARA PROTECCIÓN DE TALUD TIPO 1 |  | 180d | 2023-08-16 | 2024-06-17 | A1210 SS+6d, A1380 | 0d |  |  |
| A1310 |  | GAVIÓN (INCLUYE INSTALACIÓN) |  | 136d | 2023-08-16 | 2024-04-25 | A1260 SS+12d | 0.5d | 0d |  |
| A1290 |  | RELLENO CON MATERIAL PROPIO |  | 173d | 2023-08-23 | 2024-06-15 | A1420, A1200 SS+6d | 4d |  |  |
| A1320 |  | MURO ESCOLLERA |  | 66d | 2023-09-27 | 2023-12-15 | A1310 SS+35d | 82d |  |  |
| A1280 |  | RELLENO COMPACTADO CON MATERIAL PARA AFIRMADO EN CORONA |  | 79d | 2024-03-19 | 2024-06-20 | A1200 FF+3d, A1430 | 0d |  |  |
| A1300 |  | TRATAMIENTO DE TALUD CON GEOCELDAS (INCLUYE RELLENO DE GRAVAS) |  | 40d | 2024-04-01 | 2024-05-18 | A1260 SS+127d | 28d |  |  |

| ID | WBS | Activity | Duration | Start | Finish | Predecessors | Total float | Free float | Calendar |
| --- | --- | --- | --- | --- | --- | --- | --- | --- | --- |
|  | 2 | **REFUERZO EN DIQUES EXISTENTES** |  | 2023-05-24 | 2023-08-03 |  |  |  |  |
| A1440 |  | RECUPERACIÓN DE ROCA EN DIQUES EXISTENTES | 56d | 2023-05-24 | 2023-08-01 | A1080 SS+6d | 196d |  |  |
| A1340 |  | EXCAVACIÓN EN MATERIAL SUELTO, CON EQUIPO | 21d | 2023-05-31 | 2023-06-24 | A1040 SS+6d | 0d |  |  |
| A1350 |  | EXCAVACIÓN EN ROCA SUELTA CON EQUIPO | 21d | 2023-05-31 | 2023-06-24 | A1340 SS | 0d |  |  |
| A1360 |  | EXCAVACION DE UÑA EN MATERIAL CON NIVEL FREATICO | 22d | 2023-06-03 | 2023-06-30 | A1350 SS+3d | 2d | 0d |  |
| A1400 |  | GEOTEXTIL NO TEJIDO CLASE 1, INCLUYE INSTALACIÓN | 20d | 2023-06-10 | 2023-07-05 | A1360 SS+6d | 12d | 0d |  |
| A1370 |  | CONFORMACIÓN Y COMPACTACIÓN DE DIQUE | 12d | 2023-06-24 | 2023-07-10 | A1420 SS | 0d |  |  |
| A1390 |  | ENROCADO Y ACOMODO DE ROCA EN UÑA DE DIQUE EXISTENTE | 15d | 2023-06-24 | 2023-07-13 | A1400 SS+12d | 12d | 0d |  |
| A1420 |  | RELLENO CON MATERIAL PROPIO | 12d | 2023-06-24 | 2023-07-10 | A1350 | 0d |  |  |
| A1380 |  | ENROCADO Y ACOMODO DE ROCA EN TALUD DE DIQUE EXISTENTE | 27d | 2023-06-28 | 2023-08-02 | A1390 SS+3d | 12d | 0d |  |
| A1410 |  | RELLENO COMPACTADO CON MATERIAL PARA AFIRMADO EN CORONA | 16d | 2023-07-13 | 2023-08-03 | A1380 SS+12d | 115d | 0d |  |
| A1430 |  | PERFILADO Y COMPACTACIÓN DE CORONA EN DIQUE EXISTENTE | 16d | 2023-07-13 | 2023-08-03 | A1410 SS | 115d |  |  |
|  | 5 | **COMPONENTE DE INTERFERENCIAS** |  | 2023-06-07 | 2024-05-31 |  |  |  |  |
|  | 1 | **OBRAS DE RIEGO** |  | 2023-07-10 | 2023-12-15 |  |  |  |  |
| A1450 |  | OBRAS DE RIEGO | 131d | 2023-07-10 | 2023-12-15 | A1170 SS+12d | 17d | 0d |  |
|  | 2 | **OBRAS DE REDES** |  | 2023-06-07 | 2023-12-05 |  |  |  |  |
| A1620 |  | OBRAS DE REDES | 150d | 2023-06-07 | 2023-12-05 | A1040 SS+12d | 90d |  |  |
|  | 3 | **CRUCE VIAL** |  | 2024-03-16 | 2024-05-31 |  |  |  |  |
| A1710 |  | CRUCE VIAL | 64d | 2024-03-16 | 2024-05-31 | A1450 FS+1d | 17d |  |  |
|  | 4 | **DEMOLICIÓN DE OBRAS DE CONCRETO EXISTENTE** |  | 2023-06-24 | 2023-08-22 |  |  |  |  |
| A1900 |  | DEMOLICIÓN DE OBRA DE CONCRETO EXISTENTE | 47d | 2023-06-24 | 2023-08-22 | A1340 | 252d |  | 2T - 6x1 - 8 hr |
|  | 6 | **TRABAJOS DE CIERRE** |  | 2023-05-17 | 2024-06-18 |  |  |  |  |
| A1910 |  | MANEJO AMBIENTAL, MONITOREOS Y CONTINGENCIAS, Y CIERRE DE OBRA | 330d | 2023-05-17 | 2024-06-18 | A1080 SS | 2d |  | 2T - 6x1 - 8 hr |
|  | 2 | **INFRAESTRUCTURA VERDE Y PAISAJISMO** |  | 2023-12-15 | 2024-05-21 |  |  |  |  |
|  | 1 | **INFRAESTRUCTURA VERDE Y PAISAJISMO** |  | 2023-12-15 | 2024-05-21 |  |  |  |  |
| A1950 |  | INFRAESTRUCTURA | 130d | 2023-12-15 | 2024-05-21 | A1310 SS+101d | 29d | 0d | 2T - 6x1 - 8 hr |

| ID | WBS | Activity | Duration | Start | Finish | Predecessors | Total float | Calendar |
| --- | --- | --- | --- | --- | --- | --- | --- | --- |
|  | 2 | **ESTRUCTURAS** |  | 2024-01-17 | 2024-02-16 |  |  |  |
| A1970 |  | ESTRUCTURAS | 26d | 2024-01-17 | 2024-02-16 | A1950 SS+26d | 104d | 2T - 6x1 - 8 hr |
